# Home Construction

How a schedule from Primavera P6 changed from version to version. A marks actual dates.

## Version 1 (data date 2014-10-23, saved 2015-04-07, file c07_CONS_HOME_tut01.xer)

| ID | WBS | Task | Duration | Start | Finish | Predecessors | Complete | Total float |
| --- | --- | --- | --- | --- | --- | --- | --- | --- |
| A1000 |  | Project Start | 0d | 2014-10-14 A | 2014-10-14 A |  | 100% |  |
| A1010 |  | Project Management | 32d | 2014-10-14 A | 2014-11-28 | A1000 SS | 6% | 1d |
| A1020 |  | Project Complete | 0d | 2014-11-28 | 2014-11-28 | A1010 FF, A1150, A1170 FF, A1210 FF, A1240 FF |  | 1d |
|  | 1 | **Grading** |  | 2014-10-14 | 2014-10-18 |  |  |  |
| A1030 |  | Survey and mark out Site | 2d | 2014-10-14 A | 2014-10-15 A | A1000 SS | 100% |  |
| A1040 |  | Grade Site | 5d | 2014-10-15 A | 2014-10-18 A | A1030 | 100% |  |
|  | 2 | **Foundation** |  | 2014-10-18 | 2014-11-01 |  |  |  |
| A1050 |  | Laying of Foundation | 2d | 2014-10-18 A | 2014-10-22 A | A1040 | 100% |  |
| A1060 |  | Slab Plumbing | 1d | 2014-10-23 | 2014-10-23 | A1050 |  | 0d |
| A1070 |  | Pour and float slab concrete | 8d | 2014-10-23 | 2014-11-01 | A1060 |  | 0d |
|  | 3 | **Structure** |  | 2014-10-23 | 2014-11-29 |  |  |  |
|  | 1 | **Framing** |  | 2014-11-12 | 2014-11-25 |  |  |  |
| A1080 |  | Exterior Walls | 6d | 2014-11-12 | 2014-11-19 | A1070 FS+7d |  | 0d |
| A1090 |  | Interior Walls | 4d | 2014-11-19 | 2014-11-25 | A1080 |  | 5d |
| A1100 |  | Exterior Cladding | 2d | 2014-11-19 | 2014-11-21 | A1080 |  | 1d |
|  | 2 | **Roof** |  | 2014-11-19 | 2014-11-25 |  |  |  |
| A1110 |  | Truss Placing | 2d | 2014-11-19 | 2014-11-21 | A1080 |  | 2d |
| A1120 |  | Roof Sheeting | 1d | 2014-11-21 | 2014-11-22 | A1110 |  | 2d |
| A1130 |  | Place Paper and Shingles | 2d | 2014-11-22 | 2014-11-25 | A1120 |  | 2d |
|  | 3 | **Interior** |  | 2014-10-23 | 2014-11-29 |  |  |  |
|  | 1 | **Mechanical** |  | 2014-11-26 | 2014-11-27 |  |  |  |
| A1140 |  | HVAC Ducting | 2d | 2014-11-26 | 2014-11-27 | A1130 |  | 2d |
| A1150 |  | Install HVAC Unit | 1d | 2014-11-26 | 2014-11-26 | A1140 SS |  | 3d |
|  | 2 | **Electrical** |  | 2014-11-19 | 2014-11-26 |  |  |  |
| A1160 |  | Breaker Box and Rough Wiring | 3d | 2014-11-19 | 2014-11-22 | A1080 |  | 3d |
| A1170 |  | Finish Wiring | 3d | 2014-11-22 | 2014-11-26 | A1160 |  | 3d |
|  | 3 | **Plumbing** |  | 2014-11-19 | 2014-11-25 |  |  |  |
| A1180 |  | Install Rough Plumbing Lines | 4d | 2014-11-19 | 2014-11-25 | A1080 |  | 0d |
|  | 4 | **Decor** |  | 2014-10-23 | 2014-11-29 |  |  |  |
| A1210 |  | Kitchen Cabinets | 5d | 2014-10-23 | 2014-10-29 |  |  | 26d |
| A1190 |  | Placing Doors | 2d | 2014-11-25 | 2014-11-26 | A1180 |  | 0d |
| A1200 |  | Doors Casing and Baseboards | 3d | 2014-11-26 | 2014-11-29 | A1190 |  | 0d |
|  | 4 | **Exterior** |  | 2014-11-21 | 2014-11-27 |  |  |  |
| A1220 |  | Place Windows | 2d | 2014-11-21 | 2014-11-25 | A1100 |  | 1d |
| A1230 |  | Window Sidings | 3d | 2014-11-25 | 2014-11-27 | A1220 |  | 1d |
|  | 5 | **Landscaping** |  | 2014-11-27 | 2014-11-28 |  |  |  |
| A1240 |  | Tree Plantings | 1d | 2014-11-27 | 2014-11-28 | A1230 |  | 1d |

## Version 2 (data date 2018-10-09, saved 2018-11-17, file c05_CONS_HOME_tut02.xer)

Last finish 2014-11-29 → 2019-01-22 (+1515d). Complete tasks 4 → 0.

Added:

| ID | Task | Duration | Start | Finish | Predecessors | Resources |
| --- | --- | --- | --- | --- | --- | --- |
| A1040 | Site Demarcation | 1d | 2018-10-11 | 2018-10-12 | A1030 | Land Surveyor [8 h] |
| A1050 | Excavation | 3d | 2018-10-12 | 2018-10-17 | A1040 | Excavator [21 h] |
| A1090 | Pour and Float Slab Concrete | 2d | 2018-10-20 | 2018-10-24 | A1080 | Concrete [16 CY] |
| 1 | **Mechnical** |  | 2018-12-22 | 2018-12-28 |  |  |
| A1240 | Place Window | 12d | 2018-12-26 | 2019-01-09 | A1120 | Glass & Glazing Subcontractor [96 h]; Finish Carpenter [96 h] |

Removed: A1070 Pour and float slab concrete; Mechanical; A1160 Breaker Box and Rough Wiring

Changed:

| ID | Task | Start | Finish | Duration | Complete | Total float | Predecessors | Other |
| --- | --- | --- | --- | --- | --- | --- | --- | --- |
| A1000 | Project Start | 2014-10-14 A → 2018-10-09 (+1456d) | 2014-10-14 A → 2018-10-09 (+1456d) |  | 100% → 0% | none → 76d |  |  |
| A1010 | Project Management | 2014-10-14 A → 2018-10-09 (+1456d) | 2014-11-28 → 2019-01-22 (+1516d) | 32d → 85d | 6% → 0% | 1d → 0d |  | resources Daniel Muller [256 h] → Daniel Muller [680 h] |
| A1020 | Project Complete | 2014-11-28 → 2019-01-22 (+1516d) | 2014-11-28 → 2019-01-22 (+1516d) |  |  | 1d → 0d | A1010 FF, A1170, A1190 FF, A1230 FF, A1260 FF → A1010 FF, A1170, A1190, A1230, A1260 |  |
| 1 | **Grading** | 2014-10-14 → 2018-10-09 (+1456d) | 2014-10-18 → 2018-10-18 (+1461d) |  |  |  |  |  |
| A1030 | Survey and mark out site | 2014-10-14 A → 2018-10-09 (+1456d) | 2014-10-15 A → 2018-10-11 (+1457d) | 2d → 3d | 100% → 0% | none → 76d |  | was named Survey and mark out Site; resources Land Surveyor [16 h] → Land Surveyor [24 h] |
| A1060 | Grade Site | 2014-10-15 A → 2018-10-17 (+1463d) | 2014-10-18 A → 2018-10-18 (+1461d) | 5d → 2d | 100% → 0% | none → 76d | A1030 → A1050 | resources Operating Engineer [40 h] → Process Operations [16 h] |
| 2 | **Foundation** | 2014-10-18 → 2018-10-09 (+1452d) | 2014-11-01 → 2018-10-24 (+1453d) |  |  |  |  |  |
| A1070 | Laying of Foundation | 2014-10-18 A → 2018-10-09 (+1452d) | 2014-10-22 A → 2018-10-12 (+1451d) | 2d → 4d | 100% → 0% | none → 0d | A1060 → none | resources Engineer Labor [16 h]; Steel Crew [16 h]; Carpentry Crew [16 h]; Concrete [16 cu yd]; Masonry Crew [16 h] → Laborer Construction [32 h]; Ironworker [32 h]; Finish Carpenter [32 h]; Concrete [32 CY]; Mason [32 h] |
| A1080 | Slab Plumbing | 2014-10-23 → 2018-10-12 (+1450d) | 2014-10-23 → 2018-10-20 (+1458d) | 1d → 7d |  |  |  | resources Plumbing Crew [8 h] → Plumber [56 h] |
| 3 | **Structure** | 2014-10-23 → 2018-10-09 (+1447d) | 2014-11-29 → 2019-01-22 (+1515d) |  |  |  |  |  |
| 1 | **Framing** | 2014-11-12 → 2018-10-24 (+1442d) | 2014-11-25 → 2018-12-25 (+1491d) |  |  |  |  |  |
| A1100 | Exterior Walls | 2014-11-12 → 2018-10-24 (+1442d) | 2014-11-19 → 2018-11-17 (+1459d) | 6d → 20d |  |  | Pour and float slab concrete FS+7d → A1090 | resources Masonry Crew [48 h] → Mason [160 h]; Finishes & Fit-out Subcontractor [160 h] |
| A1110 | Interior Walls | 2014-11-19 → 2018-11-17 (+1459d) | 2014-11-25 → 2018-12-19 (+1485d) | 4d → 25d |  | 5d → 27d |  | resources Masonry Crew [32 h] → Mason [200 h]; Finishes & Fit-out Subcontractor [200 h] |
| A1120 | Exterior Cladding | 2014-11-19 → 2018-11-17 (+1459d) | 2014-11-21 → 2018-12-25 (+1495d) | 2d → 30d |  | 1d → 0d |  | resources Masonry Crew [16 h] → Finishes & Fit-out Subcontractor [240 h]; Mason [240 h] |
| 2 | **Roof** | 2014-11-19 → 2018-11-17 (+1459d) | 2014-11-25 → 2018-12-22 (+1488d) |  |  |  |  |  |
| A1130 | Truss Placing | 2014-11-19 → 2018-11-17 (+1459d) | 2014-11-21 → 2018-12-06 (+1476d) | 2d → 15d |  | 2d → 19d |  | resources Steel Crew [16 h] → Ironworker [120 h] |
| A1140 | Roof Sheeting | 2014-11-21 → 2018-12-06 (+1476d) | 2014-11-22 → 2018-12-19 (+1488d) | 1d → 10d |  | 2d → 19d |  | resources Skilled Laborer [8 h] → Laborer Construction [80 h] |
| A1150 | Place Paper and Shingles | 2014-11-22 → 2018-12-19 (+1488d) | 2014-11-25 → 2018-12-22 (+1488d) | 2d → 3d |  | 2d → 19d |  | resources Skilled Laborer [16 h] → Laborer Construction [24 h] |
| 3 | **Interior** | 2014-10-23 → 2018-10-09 (+1447d) | 2014-11-29 → 2018-12-28 (+1490d) |  |  |  |  |  |
| A1160 | HVAC Ducting | 2014-11-26 → 2018-12-22 (+1487d) | 2014-11-27 → 2018-12-26 (+1490d) | 2d → 3d |  | 2d → 19d |  | resources Richard Collins [16 h] → Richard Collins [24 h] |
| A1170 | Install HVAC Unit | 2014-11-26 → 2018-12-26 (+1491d) | 2014-11-26 → 2018-12-28 (+1493d) | 1d → 2d |  | 3d → 19d | A1160 SS → A1160 | resources Richard Collins [8 h] → Richard Collins [16 h] |
| 2 | **Electrical** | 2014-11-19 → 2018-11-17 (+1459d) | 2014-11-26 → 2018-12-01 (+1466d) |  |  |  |  |  |
| A1180 | Breaker Box and Rough Wire | 2014-11-19 → 2018-11-17 (+1459d) | 2014-11-25 → 2018-11-23 (+1459d) | 4d → 5d |  | 0d → 40d |  | was named Install Rough Plumbing Lines; resources Plumbing Crew [32 h] → Electrician [40 h] |
| A1190 | Finish Wiring | 2014-11-22 → 2018-11-23 (+1462d) | 2014-11-26 → 2018-12-01 (+1466d) | 3d → 7d |  | 3d → 40d | Breaker Box and Rough Wiring → A1180 | resources Electrical Crew [24 h] → Electrician [56 h] |
| 3 | **Plumbing** | 2014-11-19 → 2018-11-17 (+1459d) | 2014-11-25 → 2018-11-30 (+1466d) |  |  |  |  |  |
| A1200 | Install Rough plumbing lines | 2014-11-26 → 2018-11-17 (+1452d) | 2014-11-29 → 2018-11-30 (+1462d) | 3d → 10d |  | 0d → 28d | A1210 → A1100 | was named Doors Casing and Baseboards; resources Carpentry Crew [24 h] → Plumber [80 h] |
| 4 | **Decor** | 2014-10-23 → 2018-10-09 (+1447d) | 2014-11-29 → 2018-12-18 (+1480d) |  |  |  |  |  |
| A1230 | Kitchen Cabinets | 2014-10-23 → 2018-10-09 (+1447d) | 2014-10-29 → 2018-10-19 (+1451d) | 5d → 10d |  | 26d → 75d |  | resources Carpentry Crew [40 h] → Finish Carpenter [80 h] |
| A1210 | Placing Doors | 2014-11-25 → 2018-11-30 (+1466d) | 2014-11-26 → 2018-12-11 (+1476d) | 2d → 8d |  | 0d → 28d | A1180 → A1200 | resources Carpentry Crew [16 h] → Finish Carpenter [64 h] |
| A1220 | Door Placings and Baseboards | 2014-11-21 → 2018-12-11 (+1481d) | 2014-11-25 → 2018-12-18 (+1484d) | 2d → 6d |  | 1d → 28d | A1120 → A1210 | was named Place Windows; resources Glass Crew [16 h] → Finish Carpenter [48 h] |
| 5 | **Exterior** | 2014-11-21 → 2018-12-26 (+1496d) | 2014-11-27 → 2019-01-16 (+1511d) |  |  |  |  |  |
| A1250 | Window Sidings | 2014-11-25 → 2019-01-09 (+1506d) | 2014-11-27 → 2019-01-16 (+1511d) | 3d → 5d |  | 1d → 0d | A1220 → A1240 | resources Carpentry Crew [24 h] → Finish Carpenter [40 h] |
| 4 | **Landscaping** | 2014-11-27 → 2019-01-16 (+1511d) | 2014-11-28 → 2019-01-22 (+1516d) |  |  |  |  |  |
| A1260 | Tree Plantings | 2014-11-27 → 2019-01-16 (+1511d) | 2014-11-28 → 2019-01-22 (+1516d) | 1d → 5d |  | 1d → 0d |  | resources Landscape Crew [8 h] → Landscaping Subcontractor [40 h] |

## Version 3 (data date 2018-10-24, saved 2018-11-26, file c07_CONS_HOME_tut01.xer)

Last finish 2019-01-22 → 2019-01-31 (+9d). Complete tasks 0 → 6.

Changed:

| ID | Task | Start | Finish | Complete | Total float | Predecessors | Other |
| --- | --- | --- | --- | --- | --- | --- | --- |
| A1000 | Project Start | 2018-10-09 A | 2018-10-09 A | 0% → 100% | 76d → none |  |  |
| A1010 | Project Management | 2018-10-09 A | 2019-01-22 → 2019-01-31 (+9d) | 0% → 5% |  |  |  |
| A1020 | Project Complete | 2019-01-22 → 2019-01-31 (+9d) | 2019-01-22 → 2019-01-31 (+9d) |  |  | A1010 FF, A1170, A1190, A1230, A1260 → A1010 FF, A1170, A1190, A1230, A1260, A1170 FF, A1190 FF, A1230 FF, A1260 FF |  |
| 1 | **Grading** |  | 2018-10-18 → 2018-10-24 (+6d) |  |  |  |  |
| A1030 | Survey and mark out site | 2018-10-09 A | 2018-10-11 A | 0% → 100% | 76d → none |  |  |
| A1040 | Site Demarcation | 2018-10-11 A | 2018-10-12 A | 0% → 100% | 76d → none |  |  |
| A1050 | Excavation | 2018-10-12 A | 2018-10-17 A | 0% → 100% | 76d → none |  |  |
| A1060 | Grade Site | 2018-10-17 A | 2018-10-18 → 2018-10-24 A (+6d) | 0% → 100% | 76d → none |  |  |
| 2 | **Foundation** | 2018-10-09 → 2018-10-23 (+14d) | 2018-10-24 → 2018-11-02 (+9d) |  |  |  |  |
| A1070 | Laying of Foundation | 2018-10-09 → 2018-10-23 A (+14d) | 2018-10-12 → 2018-10-26 A (+14d) | 0% → 100% | 0d → none |  | resources Laborer Construction [32 h]; Ironworker [32 h]; Finish Carpenter [32 h]; Concrete [32 CY]; Mason [32 h] → Laborer Construction [32 h]; Ironworker [32 h]; Finish Carpenter [32 h]; Concrete [32 CY]; Mason [32 h]; Laborer-Construction [32 h] |
| A1080 | Slab Plumbing | 2018-10-12 → 2018-10-26 A (+14d) | 2018-10-20 → 2018-11-01 (+12d) |  |  |  |  |
| A1090 | Pour and Float Slab Concrete | 2018-10-20 → 2018-11-01 (+12d) | 2018-10-24 → 2018-11-02 (+9d) |  |  |  |  |
| 3 | **Structure** | 2018-10-09 → 2018-10-24 (+15d) | 2019-01-22 → 2019-01-31 (+9d) |  |  |  |  |
| 1 | **Framing** | 2018-10-24 → 2018-11-03 (+10d) | 2018-12-25 → 2019-01-04 (+10d) |  |  |  |  |
| A1100 | Exterior Walls | 2018-10-24 → 2018-11-03 (+10d) | 2018-11-17 → 2018-11-28 (+11d) |  |  |  |  |
| A1110 | Interior Walls | 2018-11-17 → 2018-11-28 (+11d) | 2018-12-19 → 2018-12-28 (+9d) |  |  |  |  |
| A1120 | Exterior Cladding | 2018-11-17 → 2018-11-28 (+11d) | 2018-12-25 → 2019-01-04 (+10d) |  |  |  |  |
| 2 | **Roof** | 2018-11-17 → 2018-11-28 (+11d) | 2018-12-22 → 2019-01-02 (+11d) |  |  |  |  |
| A1130 | Truss Placing | 2018-11-17 → 2018-11-28 (+11d) | 2018-12-06 → 2018-12-18 (+12d) |  |  |  |  |
| A1140 | Roof Sheeting | 2018-12-06 → 2018-12-18 (+12d) | 2018-12-19 → 2018-12-28 (+9d) |  |  |  | resources Laborer Construction [80 h] → Laborer Construction [80 h]; Laborer-Construction [80 h] |
| A1150 | Place Paper and Shingles | 2018-12-19 → 2018-12-29 (+10d) | 2018-12-22 → 2019-01-02 (+11d) |  |  |  | resources Laborer Construction [24 h] → Laborer Construction [24 h]; Laborer-Construction [24 h] |
| 3 | **Interior** | 2018-10-09 → 2018-10-24 (+15d) | 2018-12-28 → 2019-01-09 (+12d) |  |  |  |  |
| 1 | **Mechnical** | 2018-12-22 → 2019-01-02 (+11d) | 2018-12-28 → 2019-01-09 (+12d) |  |  |  |  |
| A1160 | HVAC Ducting | 2018-12-22 → 2019-01-02 (+11d) | 2018-12-26 → 2019-01-05 (+10d) |  |  |  |  |
| A1170 | Install HVAC Unit | 2018-12-26 → 2019-01-05 (+10d) | 2018-12-28 → 2019-01-09 (+12d) |  |  | A1160 → A1160, A1160 SS |  |
| 2 | **Electrical** | 2018-11-17 → 2018-11-28 (+11d) | 2018-12-01 → 2018-12-13 (+12d) |  |  |  |  |
| A1180 | Breaker Box and Rough Wire | 2018-11-17 → 2018-11-28 (+11d) | 2018-11-23 → 2018-12-05 (+12d) |  |  |  |  |
| A1190 | Finish Wiring | 2018-11-23 → 2018-12-05 (+12d) | 2018-12-01 → 2018-12-13 (+12d) |  |  |  |  |
| 3 | **Plumbing** | 2018-11-17 → 2018-11-28 (+11d) | 2018-11-30 → 2018-12-11 (+11d) |  |  |  |  |
| A1200 | Install Rough plumbing lines | 2018-11-17 → 2018-11-28 (+11d) | 2018-11-30 → 2018-12-11 (+11d) |  |  |  |  |
| 4 | **Decor** | 2018-10-09 → 2018-10-24 (+15d) | 2018-12-18 → 2018-12-28 (+10d) |  |  |  |  |
| A1230 | Kitchen Cabinets | 2018-10-09 → 2018-10-24 (+15d) | 2018-10-19 → 2018-11-03 (+15d) |  | 75d → 71d |  |  |
| A1210 | Placing Doors | 2018-11-30 → 2018-12-11 (+11d) | 2018-12-11 → 2018-12-20 (+9d) |  |  |  |  |
| A1220 | Door Casings and Baseboards | 2018-12-11 → 2018-12-20 (+9d) | 2018-12-18 → 2018-12-28 (+10d) |  |  |  | was named Door Placings and Baseboards |
| 5 | **Exterior** | 2018-12-26 → 2019-01-04 (+9d) | 2019-01-16 → 2019-01-25 (+9d) |  |  |  |  |
| A1240 | Place Windows | 2018-12-26 → 2019-01-04 (+9d) | 2019-01-09 → 2019-01-19 (+10d) |  |  |  | was named Place Window |
| A1250 | Window Sidings | 2019-01-09 → 2019-01-19 (+10d) | 2019-01-16 → 2019-01-25 (+9d) |  |  |  |  |
| 4 | **Landscaping** | 2019-01-16 → 2019-01-25 (+9d) | 2019-01-22 → 2019-01-31 (+9d) |  |  |  |  |
| A1260 | Tree Plantings | 2019-01-16 → 2019-01-25 (+9d) | 2019-01-22 → 2019-01-31 (+9d) |  |  |  |  |
